# ethernet card

Schedule from MS Project, 2003-01-20 to 2003-04-24, A marks actual dates.
No Co

## Calendars

- Standard: Mon-Fri 08:00-12:00, 13:00-17:00; Sat-Sun off. Exceptions (off unless hours are given): 2003-02-16 08:00-12:00, 13:00-17:00.

## Schedule

| ID | Task | Duration | Start | Finish | Predecessors | Complete | Constraint | Text1 |
| --- | --- | --- | --- | --- | --- | --- | --- | --- |
| 1 | Preliminary Research | 1.5w | 2003-01-20 A | 2003-01-29 A |  | 100% |  | Both |
| 2 | Setting up MSX and test | 1.5w | 2003-01-27 A | 2003-02-05 A |  | 100% | start no earlier than 2003-01-25 | Bruno |
| 3 | Preliminary Schematic Design | 1.83w | 2003-01-27 A | 2003-02-07 A |  | 100% | start no earlier than 2003-01-27 | Dave |
| 4 | First prototype testing - test interface circuitry | 3.17d | 2003-02-09 A | 2003-02-13 A |  | 100% | start no earlier than 2003-02-02 | Bruno |
| 5 | Redesign and check schematic | 2w | 2003-02-16 A | 2003-02-27 A | 4 | 100% |  | Dave |
| 6 | PCB layout | 3w | 2003-02-28 A | 2003-03-20 A | 5 | 100% |  | Bruno |
| 7 | Send out for PCB fabrication | 1w | 2003-03-21 A | 2003-03-27 A | 6 | 100% |  | Bruno |
| 8 | Board assembly | 2.2w | 2003-03-28 A | 2003-04-11 A | 7 | 100% | finish no earlier than 2003-04-11 | Dave |
| 9 | Test MSX with card plugged-in | 2.17d | 2003-04-14 A | 2003-04-16 A | 8 | 100% |  | Both |
| 10 | Driver development | 0.88w | 2003-04-13 A | 2003-04-21 A | 9 | 100% |  | Bruno |
| 11 | Final validation | 3.17d | 2003-04-21 A | 2003-04-24 A | 10 | 100% |  | Both |
